# Plantilla de calendario

Schedule from MS Project, 2022-01-10 to 2025-07-02, costs in S.

## Calendars

- Estándar: Mon-Fri 09:00-13:00, 15:00-19:00; Sat-Sun off.

## Resources

| Resource | Unit | Rate |
| --- | --- | --- |
| Topografo |  | 23.94 |
| Asistente de topografo |  | 17.08 |
| Operario | und | 23.94 |
| Oficial | bls | 18.89 |
| Peon | m3 | 17.08 |
| Jalon topografico |  | 1 |
| Nivel topografico |  | 9.75 |
| Teodolito topografico |  | 10.75 |
| Compresora neumatica 250 - 330 pcm 87 hp |  | 65 |
| Martillo neumatico de 29 kg |  | 32.5 |
| Cargador s/llanta 125-135 hp 3 yd3 |  | 175 |
| Excavadora s/orugas 115-165 hp |  | 295 |
| Camion volquete 15 m3 |  | 155 |
| Camion Cisterna 2000 gl (agua) |  | 123 |
| Rodillo Vib. Liso Aut. 7-9 t |  | 127.5 |
| Motoniveladora 125hp |  | 168 |
| Tractor de tiro Mf 265-63 hp |  | 72 |
| Barredora mecanica 10-20 hp |  | 73 |
| Camion Imprimador 1800 gl |  | 134 |
| Rodillo neumat. Aut. 5.5 - 20 t |  | 130 |
| Rodillo Tandem 8-10 t |  | 135 |
| Pavimentadora asfalto s/llantas 10'-16' |  | 165 |
| Compactadora Vib. Tipo plancha 7 hp |  | 48 |
| Rodillo Vib. Liso Aut.1.8 t |  | 55 |
| Material Granular (Subbase) | m3 | 48 |
| Material Granular (base) | m3 | 65 |
| Asfalto Liquido rc-250 | gl | 15 |
| Petroleo diesel N° 1 (kerosene Ind.) | gl | 14 |
| Clavo con Cabeza (promedio) | kg | 6 |
| Concreto Premezclado f'c = 210kg/cm2 t-1 | m3 | 300 |
| Aditivo liquido curador | gl | 23.5 |
| Madera tornillo para carpinteria | p2 | 7 |
| Mezcla asfaltica en caliente | m3 | 495 |
| Transporte de Mezcla asfaltica |  |  |
| Flete Terrestre en Plataforma (ida) |  |  |
| Flete Terrestre en Plataforma (vuelta) |  |  |
| Servicio de alquiler de contenedor |  |  |
| Disolvente Xilol | gl | 29 |
| Servicio de Fab. e Inst. Señal Informativa |  |  |
| Servicio de Fab. e Inst. Señal Octog. Preventiva |  |  |
| Pintura de transito | gl | 85 |
| Herramientas Manuales |  |  |
| Mira Topografica |  | 1.25 |

## Schedule

| ID | WBS | Task | Type | Duration | Start | Finish | Predecessors | Total slack | Free slack | Constraint | Resources | Work | Cost | Dias Calendarios (dias) (Texto1) |
| --- | --- | --- | --- | --- | --- | --- | --- | --- | --- | --- | --- | --- | --- | --- |
| 1 | 1 | **CONSTRUCCION VIAL JR. RAMON CASTILLA** |  | 908d | 2022-01-10 | 2025-07-02 |  | 0d |  |  |  | 124741h | 13,096,436.96 | 1270 |
| 2 | 1.1 | INICIO | milestone | 0d | 2022-01-10 | 2022-01-10 |  | 0d |  | start no earlier than 2022-01-10 |  |  |  |  |
| 3 | 1.2 | **Obras Provisionales, trabajos Preliminares, Seguridad y Salud** |  | 100d | 2022-01-10 | 2022-05-27 |  | 0d |  |  |  | 3241.44h | 91,801.4 | 138 |
| 4 | 1.2.1 | Movilizacion y desmovilización |  | 30d | 2022-01-10 | 2022-02-18 | 2 | 0d |  |  | Flete Terrestre en Plataforma (ida) [0.1%]; Flete Terrestre en Plataforma (vuelta) [0.1%] |  | 30,000 | 40 |
| 5 | 1.2.2 | Trazo y replanteo |  | 133.12d | 2022-01-24 | 2022-05-27 | 4FS-20d | 0d |  |  | Topografo; Asistente de topografo [200%]; Jalon topografico [50%]; Mira Topografica [200%]; Nivel topografico [50%]; Teodolito topografico [50%] | 3241.44h | 26,801.4 | 124 |
| 6 | 1.2.3 | Instalaciones provisionales |  | 30d | 2022-02-07 | 2022-03-18 | 4FS-10d | 3d |  |  | Servicio de alquiler de contenedor [0.1%] |  | 35,000 | 40 |
| 7 | 1.3 | **Demoliciones y Movimiento de Tierras** |  | 123d | 2022-02-07 | 2022-07-27 |  | 0d |  |  |  | 51792h | 3,615,213.12 | 171 |
| 8 | 1.3.1 | Demoliciones varias |  | 118d | 2022-02-07 | 2022-07-20 | 5FS-80d | 0d |  |  | Oficial [5 bls]; Peon [15 m3]; Compresora neumatica 250 - 330 pcm 87 hp [500%]; Martillo neumatico de 29 kg [1000%]; Cargador s/llanta 125-135 hp 3 yd3 [500%]; Herramientas Manuales [0.1%] | 37760h | 1,789,113.6 | 164 |
| 9 | 1.3.2 | Corte en material suelto para pavimentos |  | 71d | 2022-03-03 | 2022-06-15 | 8FS-100d, 6FS-15d | 723d | 0d |  | Peon [3 m3]; Excavadora s/orugas 115-165 hp; Herramientas Manuales [0.1%] | 2272h | 198,364.32 | 105 |
| 10 | 1.3.3 | Eliminacion de excedente D = 18 km |  | 70d | 2022-04-21 | 2022-07-27 | 9FS-40d | 723d | 0d |  | Oficial [3 bls]; Camion volquete 15 m3 [1500%]; Cargador s/llanta 125-135 hp 3 yd3 [300%] | 11760h | 1,627,735.2 | 98 |
| 11 | 1.4 | **Pavimentos** |  | 68d | 2022-06-02 | 2022-09-05 |  | 723d |  |  |  | 30156h | 7,468,959.44 | 96 |
| 12 | 1.4.1 | Conformacion de subrasante |  | 27d | 2022-06-02 | 2022-07-11 | 10FS-40d | 723d | 0d |  | Oficial [3 bls]; Peon [15 m3]; Camion Cisterna 2000 gl (agua) [150%]; Rodillo Vib. Liso Aut. 7-9 t [300%]; Motoniveladora 125hp [300%]; Herramientas Manuales [0.1%] | 5508h | 302,865.92 | 40 |
| 13 | 1.4.2 | Subbase granular e = 020 m |  | 41d | 2022-06-14 | 2022-08-09 | 12FS-20d | 723d | 0d |  | Oficial [3 bls]; Peon [15 m3]; Material Granular (Subbase) [24600 m3]; Camion Cisterna 2000 gl (agua) [150%]; Rodillo Vib. Liso Aut. 7-9 t [300%]; Motoniveladora 125hp [300%]; Herramientas Manuales [0.1%] | 8364h | 1,640,509.36 | 57 |
| 14 | 1.4.3 | Base granular e = 0.20 m |  | 41d | 2022-06-29 | 2022-08-24 | 13FS-30d | 723d | 0d |  | Oficial [3 bls]; Peon [15 m3]; Material Granular (base) [24600 m3]; Camion Cisterna 2000 gl (agua) [150%]; Rodillo Vib. Liso Aut. 7-9 t [300%]; Motoniveladora 125hp [300%]; Herramientas Manuales [0.1%] | 8364h | 2,058,709.36 | 57 |
| 15 | 1.4.4 | Imprimacion asfaltica |  | 20d | 2022-08-02 | 2022-08-29 | 14FS-17d | 723d | 0d |  | Oficial [1 bls]; Peon [3 m3]; Asfalto Liquido rc-250 [26000 gl]; Petroleo diesel N° 1 (kerosene Ind.) [6500 gl]; Tractor de tiro Mf 265-63 hp; Barredora mecanica 10-20 hp; Camion Imprimador 1800 gl; Herramientas Manuales [0.1%] | 1120h | 537,610.8 | 28 |
| 16 | 1.4.5 | Carpeta asfáltica en caliente e = 4 cm |  | 25d | 2022-08-02 | 2022-09-05 | 15FS-20d | 723d | 0d |  | Operario [2 und]; Oficial [6 bls]; Peon [20 m3]; Mezcla asfaltica en caliente [5000 m3]; Transporte de Mezcla asfaltica [0.1%]; Herramientas Manuales [0.1%]; Rodillo neumat. Aut. 5.5 - 20 t [200%]; Rodillo Tandem 8-10 t [200%]; Pavimentadora asfalto s/llantas 10'-16' [200%] | 6800h | 2,929,264 | 35 |
| 17 | 1.5 | **Obras de arte** |  | 822d | 2022-04-28 | 2025-06-20 |  | 0d |  |  |  | 37472h | 1,819,916.7 | 1150 |
| 18 | 1.5.1 | Excavación en material suelto para veredas y sardineles |  | 77d | 2022-04-28 | 2025-04-09 | 8FS-60d | 0d |  |  | Peon [20 m3]; Herramientas Manuales [0.1%] | 12320h | 222,425.6 | 1078 |
| 19 | 1.5.2 | Eliminacion de excedente D = 18 km |  | 13d | 2025-02-06 | 2025-02-24 | 18FS-45d | 0d |  |  | Oficial [1 bls]; Camion volquete 15 m3 [500%]; Cargador s/llanta 125-135 hp 3 yd3 | 728h | 100,764.56 | 19 |
| 20 | 1.5.3 | Conformacion de subrasante para veredas |  | 22d | 2025-02-25 | 2025-03-27 | 19 | 0d |  |  | Oficial [1 bls]; Peon [5 m3]; Camion Cisterna 2000 gl (agua) [50%]; Rodillo Vib. Liso Aut. 7-9 t; Motoniveladora 125hp; Herramientas Manuales [0.1%] | 1496h | 82,337.04 | 31 |
| 21 | 1.5.4 | Base para veredas e = 0.10 m |  | 35d | 2025-03-28 | 2025-05-20 | 20 | 0d |  |  | Oficial [3 bls]; Peon [18 m3]; Material Granular (base) [3300 m3]; Camion Cisterna 2000 gl (agua) [60%]; Compactadora Vib. Tipo plancha 7 hp [300%]; Rodillo Vib. Liso Aut.1.8 t [300%]; Herramientas Manuales [0.1%] | 7728h | 429,484.8 | 54 |
| 22 | 1.5.5 | Veredas de concreto fc = 210 kg/cm2, e = 4" |  | 38d | 2025-04-30 | 2025-06-20 | 21FS-15d | 0d |  |  | Operario [20 und]; Oficial [10 bls]; Peon [20 m3]; Clavo con Cabeza (promedio) [1045 kg]; Concreto Premezclado f'c = 210kg/cm2 t-1 [1995 m3]; Aditivo liquido curador [1045 gl]; Madera tornillo para carpinteria [4750 p2]; Herramientas Manuales [0.1%] | 15200h | 984,904.7 | 52 |
| 23 | 1.6 | **Señalización y Seguridad Vial** |  | 737d | 2022-09-06 | 2025-07-02 |  | 0d |  |  |  | 2080h | 100,546.3 | 1031 |
| 24 | 1.6.1 | Pintura zonal de simbolos y letras |  | 13d | 2022-09-06 | 2022-09-22 | 16 | 723d |  |  | Operario [10 und]; Peon [10 m3]; Disolvente Xilol [68.25 gl]; Pintura de transito [341.25 gl]; Herramientas Manuales [0.1%] | 2080h | 75,746.3 | 17 |
| 25 | 1.6.2 | Señales informativas |  | 5d | 2025-06-23 | 2025-06-27 | 24FS-7d, 22 | 0d |  |  | Servicio de Fab. e Inst. Señal Informativa [0.1%] |  | 13,200 |  |
| 26 | 1.6.3 | Señales preventivas octogonales 75 x 75 cm |  | 5d | 2025-06-26 | 2025-07-02 | 25FS-2d | 0d |  |  | Servicio de Fab. e Inst. Señal Octog. Preventiva [0.1%] |  | 11,600 |  |
| 27 | 1.7 | FIN | milestone | 0d | 2025-07-02 | 2025-07-02 | 16, 22, 26 | 0d |  |  |  |  |  |  |
